Schedule from MS Project, 2025-10-14 to 2025-12-28.
Microsoft

## Calendars

- Стандартный: Mon-Sun 09:00-13:00, 14:00-18:00.

## Schedule

| ID | WBS | Task | Type | Duration | Start | Finish | Predecessors | Total slack | Free slack | Constraint | ЕИ |
| --- | --- | --- | --- | --- | --- | --- | --- | --- | --- | --- | --- |
| 1 | 1 | **Ж/д пути, расположенные по адресу: Московская область, г. Коломна». Пути железнодорожные** |  | 76d | 2025-10-14 | 2025-12-28 |  | 0d |  |  |  |
| 2 | 1.1 | Оформление БГ | milestone | 0d | 2025-10-14 | 2025-10-14 |  | 76d |  | start no earlier than 2025-10-14 |  |
| 3 | 1.2 | Получение аванса | milestone | 0d | 2025-10-16 | 2025-10-16 |  | 0d |  | start no earlier than 2025-10-16 |  |
| 4 | 1.3 | **Закупка материалов** |  | 22d | 2025-10-17 | 2025-11-07 |  | 0d |  |  |  |
| 5 | 1.3.1 | Композитный брус |  | 22d | 2025-10-17 | 2025-11-07 | 3FS+1d | 0d |  | start no earlier than 2025-10-17 |  |
| 6 | 1.3.2 | Ж/Б шпалы |  | 10d | 2025-10-29 | 2025-11-07 | 3FS+1d, 5FS-10d | 51d | 0d |  |  |
| 7 | 1.3.3 | Рельсы |  | 10d | 2025-10-29 | 2025-11-07 | 3FS+1d, 5FS-10d | 51d | 0d |  |  |
| 8 | 1.3.4 | Накладки и крепёж |  | 10d | 2025-10-29 | 2025-11-07 | 3FS+1d, 5FS-10d | 51d | 0d |  |  |
| 9 | 1.3.5 | Стрелочные переводы |  | 10d | 2025-10-29 | 2025-11-07 | 3FS+1d, 5FS-10d | 0d |  |  |  |
| 10 | 1.4 | **Мобилизация** |  | 5d | 2025-10-31 | 2025-11-04 |  | 54d |  |  |  |
| 11 | 1.4.1 | Мобилизация |  | 5d | 2025-10-31 | 2025-11-04 | 6FS-8d, 7FS-8d, 8FS-8d, 9FS-8d | 54d |  |  |  |
| 12 | 1.5 | **График окон для выполнения работ** |  | 30d | 2025-11-09 | 2025-12-08 |  | 0d |  |  |  |
| 13 | 1.5.1 | Полное закрытие движения от СП2 по пути №1 - СП6 |  | 5d | 2025-11-09 | 2025-11-13 | 5FS+1d, 9FS+1d | 0d |  |  |  |
| 14 | 1.5.2 | Открытие движения от СП2 по пути №1 |  | 5d | 2025-11-14 | 2025-11-18 | 13 | 0d |  |  |  |
| 15 | 1.5.3 | Полное закрытие движения от СП2 по пути №1 - СП9 |  | 5d | 2025-11-19 | 2025-11-23 | 14 | 0d |  |  |  |
| 16 | 1.5.4 | Открытие движения от СП2 по пути №1 |  | 5d | 2025-11-24 | 2025-11-28 | 15 | 0d |  |  |  |
| 17 | 1.5.5 | Закрытие движения от СП9 по направлению к путям №9,10 - СП10 |  | 5d | 2025-11-29 | 2025-12-03 | 16 | 0d |  |  |  |
| 18 | 1.5.6 | Закрытие движения от СП9 по направлению к путям № 1,11,12,13,14 - СП11 |  | 5d | 2025-12-04 | 2025-12-08 | 17 | 0d |  |  |  |
| 19 | 1.6 | **Работы по замене стрелочных переводов** |  | 30d | 2025-11-09 | 2025-12-08 | 13SS | 20d |  |  |  |
| 20 | 1.6.1 | Стрелочный перевод №6 |  | 5d | 2025-11-09 | 2025-11-13 | 5, 9, 13SS | 45d |  |  |  |
| 21 | 1.6.2 | Стрелочный перевод №9 |  | 5d | 2025-11-19 | 2025-11-23 | 15SS | 35d |  |  | м3 |
| 22 | 1.6.3 | Стрелочный перевод №10 |  | 5d | 2025-11-29 | 2025-12-03 | 16 | 25d |  |  | м2 |
| 23 | 1.6.4 | Стрелочный перевод №11 |  | 5d | 2025-12-04 | 2025-12-08 | 18SS | 20d |  |  | м3 |
| 24 | 1.7 | **Замена существующего пути** |  | 45d | 2025-11-14 | 2025-12-28 | 14SS | 0d |  |  |  |
| 25 | 1.7.1 | замена участка пути 25м |  | 5d | 2025-11-14 | 2025-11-18 | 14SS | 40d |  |  |  |
| 26 | 1.7.2 | замена участка пути 25м |  | 5d | 2025-11-24 | 2025-11-28 | 16SS | 30d |  |  |  |
| 27 | 1.7.3 | замена участка пути 100м |  | 20d | 2025-12-09 | 2025-12-28 | 18 | 0d |  |  |  |
