Schedule from MS Project, 2025-10-14 to 2025-12-18.
Microsoft

## Calendars

- Стандартный: Mon-Sun 09:00-13:00, 14:00-18:00.

## Schedule

| ID | WBS | Task | Type | Duration | Start | Finish | Predecessors | Total slack | Free slack | Constraint | ЕИ |
| --- | --- | --- | --- | --- | --- | --- | --- | --- | --- | --- | --- |
| 1 | 1 | **Ж/д пути, расположенные по адресу: Московская область, г. Коломна». Пути железнодорожные** |  | 66d | 2025-10-14 | 2025-12-18 |  | 0d |  |  |  |
| 2 | 1.1 | Оформление БГ | milestone | 0d | 2025-10-14 | 2025-10-14 |  | 66d |  | start no earlier than 2025-10-14 |  |
| 3 | 1.2 | Получение аванса | milestone | 0d | 2025-10-16 | 2025-10-16 |  | 0d |  | start no earlier than 2025-10-16 |  |
| 4 | 1.3 | **Закупка материалов** |  | 22d | 2025-10-17 | 2025-11-07 |  | 0d |  |  |  |
| 5 | 1.3.1 | Композитный брус |  | 22d | 2025-10-17 | 2025-11-07 | 3FS+1d | 0d |  | start no earlier than 2025-10-17 |  |
| 6 | 1.3.2 | Ж/Б шпалы |  | 10d | 2025-10-29 | 2025-11-07 | 3FS+1d, 5FS-10d | 41d | 0d |  |  |
| 7 | 1.3.3 | Рельсы |  | 10d | 2025-10-29 | 2025-11-07 | 3FS+1d, 5FS-10d | 41d | 0d |  |  |
| 8 | 1.3.4 | Накладки и крепёж |  | 10d | 2025-10-29 | 2025-11-07 | 3FS+1d, 5FS-10d | 41d | 0d |  |  |
| 9 | 1.3.5 | Стрелочные переводы |  | 10d | 2025-10-29 | 2025-11-07 | 3FS+1d, 5FS-10d | 0d |  |  |  |
| 10 | 1.4 | **Мобилизация** |  | 4d | 2025-10-31 | 2025-11-03 |  | 45d |  |  |  |
| 11 | 1.4.1 | Мобилизация КиК |  | 2d | 2025-10-31 | 2025-11-01 | 6FS-8d, 7FS-8d, 8FS-8d, 9FS-8d | 47d |  |  |  |
| 12 | 1.4.2 | Мобилизация ЭЭ |  | 4d | 2025-10-31 | 2025-11-03 | 6FS-8d, 7FS-8d, 8FS-8d, 9FS-8d | 45d |  |  |  |
| 13 | 1.5 | **График окон для выполнения работ** |  | 25d | 2025-11-09 | 2025-12-03 |  | 0d |  |  |  |
| 14 | 1.5.1 | Полное закрытие движения от СП2 по пути №1 - СП6 |  | 5d | 2025-11-09 | 2025-11-13 | 5FS+1d, 9FS+1d | 0d |  |  |  |
| 15 | 1.5.2 | Открытие движения от СП2 по пути №1 |  | 5d | 2025-11-14 | 2025-11-18 | 14 | 0d |  |  |  |
| 16 | 1.5.3 | Полное закрытие движения от СП2 по пути №1 - СП9 |  | 5d | 2025-11-19 | 2025-11-23 | 15 | 0d |  |  |  |
| 17 | 1.5.4 | Закрытие движения от СП9 по направлению к путям №9,10 - СП10 |  | 5d | 2025-11-24 | 2025-11-28 | 16 | 0d |  |  |  |
| 18 | 1.5.5 | Закрытие движения от СП9 по направлению к путям № 1,11,12,13,14 - СП11 |  | 5d | 2025-11-29 | 2025-12-03 | 17 | 0d |  |  |  |
| 19 | 1.6 | **Стрелочный перевод №6** |  | 5d | 2025-11-09 | 2025-11-13 | 14SS | 35d |  |  |  |
| 20 | 1.6.1 | Разборка и демонтаж стр.перевода |  | 1d | 2025-11-09 | 2025-11-09 | 5, 9, 14SS | 35d | 0d |  |  |
| 21 | 1.6.2 | Выемка грунта (загрезнённого балласта) под основание стр.перевода |  | 1d | 2025-11-10 | 2025-11-10 | 20 | 35d | 0d |  | м3 |
| 22 | 1.6.3 | Уплотнение основания выемки вибротрамбовками |  | 1d | 2025-11-10 | 2025-11-10 | 21SS | 35d | 0d |  | м2 |
| 23 | 1.6.4 | Устройство балластного основания из щебня |  | 1d | 2025-11-10 | 2025-11-10 | 22SS | 35d | 0d |  | м3 |
| 24 | 1.6.5 | Монтаж брусьев полимерных композитных |  | 2d | 2025-11-10 | 2025-11-11 | 23FS-1d | 35d | 0d |  | шт. |
| 25 | 1.6.6 | Сборка и монтаж стрелочного перевода |  | 2d | 2025-11-10 | 2025-11-11 | 24SS | 35d | 0d |  |  |
| 26 | 1.6.7 | Монтаж брусьев полимерных композитных под переводные механизмы |  | 1d | 2025-11-12 | 2025-11-12 | 25 | 35d | 0d |  | шт. |
| 27 | 1.6.8 | Монтаж переводного механизма (флюгарки) |  | 1d | 2025-11-12 | 2025-11-12 | 26SS | 35d | 0d |  | шт. |
| 28 | 1.6.9 | Монтаж временных стыковочных путей с СП 7 и СП 9 |  | 2d | 2025-11-12 | 2025-11-13 | 27SS | 35d | 0d |  | к-т |
| 29 | 1.6.10 | Балластировка стрелочного перевода и вр.стыковочных путей |  | 1d | 2025-11-13 | 2025-11-13 | 28FS-1d | 35d | 0d |  | м3 |
| 30 | 1.6.11 | Выправка стрелочного перевода и вр.стыковочных путей |  | 1d | 2025-11-13 | 2025-11-13 | 29SS | 35d | 0d |  | м3 |
| 31 | 1.6.12 | Рихтовка стрелочного перевода и вр.стыковочных путей |  | 1d | 2025-11-13 | 2025-11-13 | 30SS | 35d |  |  |  |
| 32 | 1.6.13 | Погрузка и вывоз с места работ загрезнённого щебня, грунта и мусора |  | 5d | 2025-11-09 | 2025-11-13 | 20SS | 35d |  |  |  |
| 33 | 1.6.14 | Погрузка и вывоз с места работ демонтированных элементов стрелочного перевода |  | 5d | 2025-11-09 | 2025-11-13 | 20SS | 35d |  |  |  |
| 34 | 1.6.15 | Погрузка и вывоз с места работ демонтированных брусьев и шпалы |  | 5d | 2025-11-09 | 2025-11-13 | 20SS | 35d |  |  |  |

| ID | WBS | Task | Duration | Start | Finish | Predecessors | Total slack | Free slack | ЕИ |
| --- | --- | --- | --- | --- | --- | --- | --- | --- | --- |
| 35 | 1.7 | **Замена существующего пути участок 25 м** | 5d | 2025-11-14 | 2025-11-18 | 15SS | 30d |  |  |
| 36 | 1.7.1 | Очистка поверхностей шпалы путей и межпутья от мусора, грунта и пр. до подошвы шпалы | 1d | 2025-11-14 | 2025-11-14 | 15SS | 30d | 0d |  |
| 37 | 1.7.2 | Демонтаж рельсошпальной решётки | 1d | 2025-11-14 | 2025-11-14 | 36SS | 30d | 0d |  |
| 38 | 1.7.3 | Выемка грунта (загрезнённого балласта) под основание пути | 1d | 2025-11-14 | 2025-11-14 | 37SS | 30d | 0d |  |
| 39 | 1.7.4 | Уплотнение основания выемки вибротрамбовками | 1d | 2025-11-14 | 2025-11-14 | 38SS | 30d | 0d |  |
| 40 | 1.7.5 | Устройство балластного основания из щебня | 1d | 2025-11-14 | 2025-11-14 | 39SS | 30d | 0d |  |
| 41 | 1.7.6 | Укладка шпал железобетонных | 2d | 2025-11-15 | 2025-11-16 | 40 | 30d | 0d |  |
| 42 | 1.7.7 | Укладка и скрепление рельс | 3d | 2025-11-15 | 2025-11-17 | 41SS | 30d | 0d |  |
| 43 | 1.7.8 | Балластировка, выправка и рихтовка путей | 1d | 2025-11-18 | 2025-11-18 | 42 | 30d |  |  |
| 44 | 1.8 | **Стрелочный перевод №9** | 5d | 2025-11-19 | 2025-11-23 | 16SS | 25d |  |  |
| 45 | 1.8.1 | Разборка и демонтаж стр.перевода | 1d | 2025-11-19 | 2025-11-19 | 16SS | 25d | 0d |  |
| 46 | 1.8.2 | Выемка грунта (загрезнённого балласта) под основание стр.перевода | 1d | 2025-11-20 | 2025-11-20 | 45 | 25d | 0d | м3 |
| 47 | 1.8.3 | Уплотнение основания выемки вибротрамбовками | 1d | 2025-11-20 | 2025-11-20 | 46SS | 25d | 0d | м2 |
| 48 | 1.8.4 | Устройство балластного основания из щебня | 1d | 2025-11-20 | 2025-11-20 | 47SS | 25d | 0d | м3 |
| 49 | 1.8.5 | Монтаж брусьев полимерных композитных | 2d | 2025-11-21 | 2025-11-22 | 48 | 25d | 0d | шт. |
| 50 | 1.8.6 | Сборка и монтаж стрелочного перевода | 2d | 2025-11-21 | 2025-11-22 | 49SS | 25d | 0d |  |
| 51 | 1.8.7 | Монтаж брусьев полимерных композитных под переводные механизмы | 1d | 2025-11-22 | 2025-11-22 | 50FS-1d | 25d | 0d | шт. |
| 52 | 1.8.8 | Монтаж переводного механизма (флюгарки) | 1d | 2025-11-22 | 2025-11-22 | 51SS | 25d | 0d | шт. |
| 53 | 1.8.9 | Монтаж временных стыковочных путей с СП11 | 2d | 2025-11-22 | 2025-11-23 | 52SS | 25d | 0d | к-т |
| 54 | 1.8.10 | Балластировка стрелочного перевода и вр.стыковочных путей | 1d | 2025-11-23 | 2025-11-23 | 53FS-1d | 25d | 0d | м3 |
| 55 | 1.8.11 | Выправка стрелочного перевода и вр.стыковочных путей | 1d | 2025-11-23 | 2025-11-23 | 54SS | 25d | 0d | м3 |
| 56 | 1.8.12 | Рихтовка стрелочного перевода и вр.стыковочных путей | 1d | 2025-11-23 | 2025-11-23 | 55SS | 25d |  |  |
| 57 | 1.8.13 | Погрузка и вывоз с места работ загрезнённого щебня, грунта и мусора | 5d | 2025-11-19 | 2025-11-23 | 45SS | 25d |  |  |
| 58 | 1.8.14 | Погрузка и вывоз с места работ демонтированных элементов стрелочного перевода | 5d | 2025-11-19 | 2025-11-23 | 45SS | 25d |  |  |
| 59 | 1.8.15 | Погрузка и вывоз с места работ демонтированных брусьев и шпалы | 5d | 2025-11-19 | 2025-11-23 | 45SS | 25d |  |  |

| ID | WBS | Task | Duration | Start | Finish | Predecessors | Total slack | Free slack | ЕИ |
| --- | --- | --- | --- | --- | --- | --- | --- | --- | --- |
| 60 | 1.9 | **Стрелочный перевод №10** | 5d | 2025-11-24 | 2025-11-28 | 17SS | 20d |  |  |
| 61 | 1.9.1 | Разборка и демонтаж стр.перевода | 1d | 2025-11-24 | 2025-11-24 | 17SS | 20d | 0d |  |
| 62 | 1.9.2 | Выемка грунта (загрезнённого балласта) под основание стр.перевода | 1d | 2025-11-25 | 2025-11-25 | 61 | 20d | 0d | м3 |
| 63 | 1.9.3 | Уплотнение основания выемки вибротрамбовками | 1d | 2025-11-25 | 2025-11-25 | 62SS | 20d | 0d | м2 |
| 64 | 1.9.4 | Устройство балластного основания из щебня | 1d | 2025-11-25 | 2025-11-25 | 63SS | 20d | 0d | м3 |
| 65 | 1.9.5 | Монтаж брусьев полимерных композитных | 2d | 2025-11-26 | 2025-11-27 | 64 | 20d | 0d | шт. |
| 66 | 1.9.6 | Сборка и монтаж стрелочного перевода | 2d | 2025-11-26 | 2025-11-27 | 65SS | 20d | 0d |  |
| 67 | 1.9.7 | Монтаж брусьев полимерных композитных под переводные механизмы | 1d | 2025-11-27 | 2025-11-27 | 66FS-1d | 20d | 0d | шт. |
| 68 | 1.9.8 | Монтаж переводного механизма (флюгарки) | 1d | 2025-11-27 | 2025-11-27 | 67SS | 20d | 0d | шт. |
| 69 | 1.9.9 | Монтаж временных стыковочных путей с СП8 | 2d | 2025-11-27 | 2025-11-28 | 68SS | 20d | 0d | к-т |
| 70 | 1.9.10 | Балластировка стрелочного перевода и вр.стыковочных путей | 1d | 2025-11-28 | 2025-11-28 | 69FS-1d | 20d | 0d | м3 |
| 71 | 1.9.11 | Выправка стрелочного перевода и вр.стыковочных путей | 1d | 2025-11-28 | 2025-11-28 | 70SS | 20d | 0d | м3 |
| 72 | 1.9.12 | Рихтовка стрелочного перевода и вр.стыковочных путей | 1d | 2025-11-28 | 2025-11-28 | 71SS | 20d |  |  |
| 73 | 1.9.13 | Погрузка и вывоз с места работ загрезнённого щебня, грунта и мусора | 5d | 2025-11-24 | 2025-11-28 | 61SS | 20d |  |  |
| 74 | 1.9.14 | Погрузка и вывоз с места работ демонтированных элементов стрелочного перевода | 5d | 2025-11-24 | 2025-11-28 | 61SS | 20d |  |  |
| 75 | 1.9.15 | Погрузка и вывоз с места работ демонтированных брусьев и шпалы | 5d | 2025-11-24 | 2025-11-28 | 61SS | 20d |  |  |
| 76 | 1.10 | **Стрелочный перевод №11** | 5d | 2025-11-29 | 2025-12-03 | 18SS | 0d |  |  |
| 77 | 1.10.1 | Разборка и демонтаж стр.перевода | 1d | 2025-11-29 | 2025-11-29 | 18SS | 0d |  |  |
| 78 | 1.10.2 | Выемка грунта (загрезнённого балласта) под основание стр.перевода | 1d | 2025-11-30 | 2025-11-30 | 77 | 0d |  | м3 |
| 79 | 1.10.3 | Уплотнение основания выемки вибротрамбовками | 1d | 2025-11-30 | 2025-11-30 | 78SS | 0d |  | м2 |
| 80 | 1.10.4 | Устройство балластного основания из щебня | 1d | 2025-11-30 | 2025-11-30 | 79SS | 0d |  | м3 |
| 81 | 1.10.5 | Монтаж брусьев полимерных композитных | 2d | 2025-12-01 | 2025-12-02 | 80 | 0d |  | шт. |
| 82 | 1.10.6 | Сборка и монтаж стрелочного перевода | 2d | 2025-12-01 | 2025-12-02 | 81SS | 0d |  |  |
| 83 | 1.10.7 | Монтаж брусьев полимерных композитных под переводные механизмы | 1d | 2025-12-02 | 2025-12-02 | 82FS-1d | 0d |  | шт. |
| 84 | 1.10.8 | Монтаж переводного механизма (флюгарки) | 1d | 2025-12-02 | 2025-12-02 | 83SS | 0d |  | шт. |
| 85 | 1.10.9 | Монтаж временных стыковочных путей с СП13 | 2d | 2025-12-02 | 2025-12-03 | 84SS | 0d |  | к-т |
| 86 | 1.10.10 | Балластировка стрелочного перевода и вр.стыковочных путей | 1d | 2025-12-03 | 2025-12-03 | 85FS-1d | 0d |  | м3 |
| 87 | 1.10.11 | Выправка стрелочного перевода и вр.стыковочных путей | 1d | 2025-12-03 | 2025-12-03 | 86SS | 0d |  | м3 |
| 88 | 1.10.12 | Рихтовка стрелочного перевода и вр.стыковочных путей | 1d | 2025-12-03 | 2025-12-03 | 87SS | 0d |  |  |
| 89 | 1.10.13 | Погрузка и вывоз с места работ загрезнённого щебня, грунта и мусора | 5d | 2025-11-29 | 2025-12-03 | 77SS | 0d |  |  |
| 90 | 1.10.14 | Погрузка и вывоз с места работ демонтированных элементов стрелочного перевода | 5d | 2025-11-29 | 2025-12-03 | 77SS | 0d |  |  |
| 91 | 1.10.15 | Погрузка и вывоз с места работ демонтированных брусьев и шпалы | 5d | 2025-11-29 | 2025-12-03 | 77SS | 0d |  |  |

| ID | WBS | Task | Duration | Start | Finish | Predecessors | Total slack |
| --- | --- | --- | --- | --- | --- | --- | --- |
| 92 | 1.11 | **Замена существующего пути участок 125 м** | 15d | 2025-12-04 | 2025-12-18 | 76 | 0d |
| 93 | 1.11.1 | Очистка поверхностей шпалы путей и межпутья от мусора, грунта и пр. до подошвы шпалы | 3d | 2025-12-04 | 2025-12-06 | 76 | 0d |
| 94 | 1.11.2 | Демонтаж рельсошпальной решётки | 3d | 2025-12-04 | 2025-12-06 | 93SS | 0d |
| 95 | 1.11.3 | Выемка грунта (загрезнённого балласта) под основание пути | 3d | 2025-12-04 | 2025-12-06 | 94SS | 0d |
| 96 | 1.11.4 | Уплотнение основания выемки вибротрамбовками | 3d | 2025-12-04 | 2025-12-06 | 95SS | 0d |
| 97 | 1.11.5 | Устройство балластного основания из щебня | 3d | 2025-12-04 | 2025-12-06 | 96SS | 0d |
| 98 | 1.11.6 | Укладка шпал железобетонных | 10d | 2025-12-07 | 2025-12-16 | 97 | 0d |
| 99 | 1.11.7 | Укладка и скрепление рельс | 10d | 2025-12-07 | 2025-12-16 | 98SS | 0d |
| 100 | 1.11.8 | Балластировка, выправка и рихтовка путей | 2d | 2025-12-17 | 2025-12-18 | 99 | 0d |
